# programacion med leg

Schedule from MS Project, 2025-12-30 to 2026-04-30, status date 2026-04-14, costs in $, A marks actual dates.

## Calendars

- Estándar: Mon-Fri 09:00-13:00, 15:00-19:00; Sat-Sun off.

## Schedule

| ID | WBS | Task | Type | Duration | Start | Finish | Predecessors | Complete | Remaining | Baseline start | Baseline finish | Baseline duration | Total slack | Free slack | Constraint | Cost | Baseline cost | Actual cost |
| --- | --- | --- | --- | --- | --- | --- | --- | --- | --- | --- | --- | --- | --- | --- | --- | --- | --- | --- |
| 1 | 1 | **REMODELACION OFICINAS MEDICINA LEGAL** |  | 88d | 2025-12-30 A | 2026-04-30 |  | 36% | 56.25d | 2025-12-30 | 2026-04-30 | 88d | 0d |  |  | 1,205,592,310.97 | 1,205,592,310.97 | 129,801,874 |
| 2 | 1.1 | INICIO | milestone | 0d | 2025-12-30 A | 2025-12-30 A |  | 100% |  | 2025-12-30 | 2025-12-30 | 0d |  |  | start no earlier than 2025-12-30 |  |  |  |
| 3 | 1.2 | SUSPENSIÓN |  | 22d | 2026-02-17 A | 2026-03-18 A | 2 | 100% |  | 2026-02-17 | 2026-03-18 | 22d |  |  | finish no earlier than 2026-03-18 |  |  |  |
| 4 | 1.3 | **PRELIMINARES** |  | 7d | 2026-03-19 A | 2026-03-27 A |  | 100% |  | 2026-03-19 | 2026-03-27 | 7d |  |  |  | 12,020,677 | 12,020,677 | 12,020,677 |
| 5 | 1.3.1 | Demolición de acabado de piso en enchape cerámico, epóxico o tablón de gres y afinado hasta de 10 cm. VER FICHA TECNICA |  | 5d | 2026-03-20 A | 2026-03-26 A | 9SS+1d | 100% |  | 2026-03-20 | 2026-03-26 | 5d |  |  |  | 742,950 | 742,950 | 742,950 |
| 6 | 1.3.2 | Pase de placa de diametro 0,12 m. VER FICHA TECNICA. |  | 3d | 2026-03-20 A | 2026-03-24 A | 5SS | 100% |  | 2026-03-20 | 2026-03-24 | 3d |  |  |  | 111,760 | 111,760 | 111,760 |
| 7 | 1.3.3 | Desmonte de cielorraso en superboard, VER FICHA TECNICA |  | 3d | 2026-03-20 A | 2026-03-24 A | 5SS | 100% |  | 2026-03-20 | 2026-03-24 | 3d |  |  |  | 5,105,400 | 5,105,400 | 5,105,400 |
| 8 | 1.3.4 | Desmonte y reinstalación de puertas o ventanas. VER FICHA TECNICA |  | 4d | 2026-03-23 A | 2026-03-26 A | 7SS+1d | 100% |  | 2026-03-23 | 2026-03-26 | 4d |  |  |  | 203,200 | 203,200 | 203,200 |
| 9 | 1.3.5 | Desmonte, almacenaje y reinstalación de mobiliario y equipos existentes, VER FICHA TECNICA |  | 3d | 2026-03-19 A | 2026-03-23 A | 3 | 100% |  | 2026-03-19 | 2026-03-23 | 3d |  |  |  | 5,530,850 | 5,530,850 | 5,530,850 |
| 10 | 1.3.6 | Raspado de estuco y pintura de muro hasta encontrar pañete, VER FICHA TECNICA |  | 3d | 2026-03-25 A | 2026-03-27 A | 7 | 100% |  | 2026-03-25 | 2026-03-27 | 3d |  |  |  | 103,632 | 103,632 | 103,632 |
| 11 | 1.3.7 | Demolición de muro en mamposteria, VER FICHA TECNICA |  | 3d | 2026-03-20 A | 2026-03-24 A | 5SS | 100% |  | 2026-03-20 | 2026-03-24 | 3d |  |  |  | 222,885 | 222,885 | 222,885 |
| 12 | 1.4 | **INSTALACIONES HIDROSANITARIAS** |  | 11d | 2026-03-30 A | 2026-04-13 A |  | 100% |  | 2026-03-30 | 2026-04-13 | 11d |  |  |  | 5,744,210 | 5,744,210 | 5,744,210 |
| 13 | 1.4.1 | Suministro e instalacion de punto Sanitario de 2", VER FICHA TECNICA |  | 1d | 2026-04-02 A | 2026-04-02 A | 14 | 100% |  | 2026-04-02 | 2026-04-02 | 1d |  |  |  | 914,400 | 914,400 | 914,400 |
| 14 | 1.4.2 | Suministro e instalacion de tubería PVC-sanitaria ∅2", VER FICHA TECNICA |  | 3d | 2026-03-30 A | 2026-04-01 A | 10 | 100% |  | 2026-03-30 | 2026-04-01 | 3d |  |  |  | 548,640 | 548,640 | 548,640 |
| 15 | 1.4.3 | Suministro e instalacion de punto agua fría de ∅1/2", VER FICHA TECNICA |  | 2d | 2026-04-10 A | 2026-04-13 A | 16 | 100% |  | 2026-04-10 | 2026-04-13 | 2d |  |  |  | 194,310 | 194,310 | 194,310 |
| 16 | 1.4.4 | Suministro e instalacion de red agua fría PVC presión ∅1/2", VER FICHA TECNICA |  | 4d | 2026-04-06 A | 2026-04-09 A | 17 | 100% |  | 2026-04-06 | 2026-04-09 | 4d |  |  |  | 670,560 | 670,560 | 670,560 |
| 17 | 1.4.5 | Construcción de punto Sanitario de 4", VER FICHA TECNICA |  | 2d | 2026-04-02 A | 2026-04-03 A | 18 | 100% |  | 2026-04-02 | 2026-04-03 | 2d |  |  |  | 88,900 | 88,900 | 88,900 |
| 18 | 1.4.6 | Red Sanitaria en tuberia en PVC de 4", VER FICHA TECNICA |  | 3d | 2026-03-30 A | 2026-04-01 A | 14SS | 100% |  | 2026-03-30 | 2026-04-01 | 3d |  |  |  | 1,778,000 | 1,778,000 | 1,778,000 |
| 19 | 1.4.7 | Suministro e instalacion de registro PVC 1/2" VER FICHA TECNICA |  | 3d | 2026-04-06 A | 2026-04-08 A | 17 | 100% |  | 2026-04-06 | 2026-04-08 | 3d |  |  |  | 274,320 | 274,320 | 274,320 |
| 20 | 1.4.8 | Conexión desague a red existente VER FICHA TECNICA |  | 1d | 2026-04-06 A | 2026-04-06 A | 17 | 100% |  | 2026-04-06 | 2026-04-06 | 1d |  |  |  | 292,100 | 292,100 | 292,100 |
| 21 | 1.4.9 | Suministro e instalación de tapa registro de 20×20 cm de empotrar, VER FICHA TECNICA |  | 2d | 2026-04-07 A | 2026-04-08 A | 20 | 100% |  | 2026-04-07 | 2026-04-08 | 2d |  |  |  | 982,980 | 982,980 | 982,980 |
| 22 | 1.5 | **INSTALACIONES ELÉCTRICAS Y MECÁNICAS** |  | 23d | 2026-03-30 A | 2026-04-29 |  | 25% | 17.25d | 2026-03-30 | 2026-04-29 | 23d | 1d |  |  | 258,748,530 | 258,748,530 | 73,146,412 |
| 23 | 1.5.1 | **INSTALACIONES ELECTRICAS E ILUMINACION** |  | 23d | 2026-03-30 A | 2026-04-29 |  | 40% | 13.71d | 2026-03-30 | 2026-04-29 | 23d | 1d |  |  | 174,223,680 | 174,223,680 | 73,146,412 |
| 24 | 1.5.1.1 | Desmonte, retiro y disposición final en botadero autorizado ó sitio donde la Entidad indique, de instalaciones eléctricas VER FICHA TECNICA |  | 4d | 2026-04-01 A | 2026-04-06 A | 10FS+2d | 100% |  | 2026-04-01 | 2026-04-06 | 4d |  |  |  | 635,000 | 635,000 | 635,000 |
| 25 | 1.5.1.2 | Suministro de materiales y mano de obra para Instalación de tomacorriente doble, tierra aislada color blanco empotrado, 2P+T 15A 125V; VER FICHA TECNICA |  | 2d | 2026-04-27 | 2026-04-28 | 40SS |  |  | 2026-04-27 | 2026-04-28 | 2d | 1d | 0d |  | 106,680 | 106,680 |  |
| 26 | 1.5.1.3 | Suministro de materiales y mano de obra para instalacion de tomacorriente doble, tierra aislada color blanco en canaleta, 2P+T 15A 125V; VER FICHA TECNICA. |  | 3d | 2026-04-27 | 2026-04-29 | 25SS |  |  | 2026-04-27 | 2026-04-29 | 3d | 1d |  |  | 762,000 | 762,000 |  |
| 27 | 1.5.1.4 | Suministro de materiales y mano de obra para Instalación de tomacorriente doble GFCI empotrado, 2P+T 15A 125V; VER FICHA TECNICA |  | 2d | 2026-04-27 | 2026-04-28 | 25SS |  |  | 2026-04-27 | 2026-04-28 | 2d | 2d |  |  | 1,016,000 | 1,016,000 |  |
| 28 | 1.5.1.5 | Suministro de materiales y mano de obra para Instalación de tomacorriente doble GFCI empotrado, 2P+T 15A 125V; VER FICHA TECNICA |  | 3d | 2026-04-27 | 2026-04-29 | 25SS |  |  | 2026-04-27 | 2026-04-29 | 3d | 1d |  |  | 800,100 | 800,100 |  |
| 29 | 1.5.1.6 | Suministro de materiales y mano de obra para Instalación de salida a 120V para tomacorriente normal, grado comercial 2P+T 15A 120V, VER FICHA TECNICA |  | 3d | 2026-04-27 | 2026-04-29 | 25SS |  |  | 2026-04-27 | 2026-04-29 | 3d | 1d |  |  | 6,629,400 | 6,629,400 |  |
| 30 | 1.5.1.7 | Suministro de materiales y mano de obra para Instalación de salida a 120V para tomacorriente regulada color naranja, grado hospitalario 2P+T 15A 120V, circuito compartido; VER FICHA TECNICA |  | 3d | 2026-04-27 | 2026-04-29 | 25SS |  |  | 2026-04-27 | 2026-04-29 | 3d | 1d |  |  | 1,280,160 | 1,280,160 |  |
| 31 | 1.5.1.8 | Suministro de materiales y mano de obra para Instalación de salida a 120V para tomacorriente regulada color naranja en canaleta, grado hospitalario 2P+T 15A 120V, circuito compartido; VER FICHA TECNICA |  | 3d | 2026-04-27 | 2026-04-29 | 25SS |  |  | 2026-04-27 | 2026-04-29 | 3d | 1d |  |  | 8,750,300 | 8,750,300 |  |
| 32 | 1.5.1.9 | Suministro de materiales y mano de obra para instalación de salida especial 120V toma de seguridad NEMA L5-30 . Circuito Regulado o dedicado; VER FICHA TECNICA |  | 3d | 2026-04-27 | 2026-04-29 | 25SS |  |  | 2026-04-27 | 2026-04-29 | 3d | 1d |  |  | 781,050 | 781,050 |  |
| 33 | 1.5.1.10 | Suministro de materiales y mano de obra para Instalación de salida para interruptor sencillo empotrado con independización del circuito de control de iluminación;VER FICHA TECNICA |  | 3d | 2026-04-27 | 2026-04-29 | 40SS |  |  | 2026-04-27 | 2026-04-29 | 3d | 1d |  |  | 751,840 | 751,840 |  |
| 34 | 1.5.1.11 | Suministro de materiales y mano de obra para Instalación de salida para interruptor doble empotrado con independización del circuito de control de iluminación; VER FICHA TECNICA |  | 3d | 2026-04-27 | 2026-04-29 | 40SS |  |  | 2026-04-27 | 2026-04-29 | 3d | 1d |  |  | 1,536,700 | 1,536,700 |  |
| 35 | 1.5.1.12 | Suministro de materiales y mano de obra para Instalación de salida para interruptor doble conmutable empotrado con independización del circuito de control de iluminación; VER FICHA TECNICA |  | 3d | 2026-04-27 | 2026-04-29 | 40SS |  |  | 2026-04-27 | 2026-04-29 | 3d | 1d |  |  | 1,981,200 | 1,981,200 |  |
| 36 | 1.5.1.13 | Suministro de materiales y mano de obra para Instalación de salida para interruptor sencillo conmutable empotrado con independización del circuito de control de iluminación;VER FICHA TECNICA |  | 3d | 2026-04-27 | 2026-04-29 | 40SS |  |  | 2026-04-27 | 2026-04-29 | 3d | 1d |  |  | 1,127,760 | 1,127,760 |  |
| 37 | 1.5.1.14 | Suministro de materiales y mano de obra para Instalación de salida para iluminación; VER FICHA TECNICA |  | 5d | 2026-04-10 A | 2026-04-16 | 61 | 60% | 2d | 2026-04-10 | 2026-04-16 | 5d | 0d |  |  | 18,206,720 | 18,206,720 | 10,924,032 |
| 38 | 1.5.1.15 | Suministro de materiales y mano de obra para Instalación de tapa ciega en acero inoxidable para caja 5800 con empaque; VER FICHA TECNICA |  | 2d | 2026-04-27 | 2026-04-28 | 39SS |  |  | 2026-04-27 | 2026-04-28 | 2d | 2d |  |  | 203,200 | 203,200 |  |
| 39 | 1.5.1.16 | Suministro de materiales y mano de obra para Instalación de tapa ciega plastica para caja 5800 con empaque; VER FICHA TECNICA. |  | 3d | 2026-04-27 | 2026-04-29 | 40SS |  |  | 2026-04-27 | 2026-04-29 | 3d | 1d | 0d |  | 64,770 | 64,770 |  |
| 40 | 1.5.1.17 | Suministro de materiales y mano de obra para Instalación de sensor de presencia para control de iluminación, Sensor 360º horizontal Voltaje 120V 60Hz 1000W, Distancia de transmisión 6 metros Material Pasta; VER FICHA TECNICA |  | 3d | 2026-04-27 | 2026-04-29 | 47 |  |  | 2026-04-27 | 2026-04-29 | 3d | 1d | 0d |  | 4,749,800 | 4,749,800 |  |
| 41 | 1.5.1.18 | Suministro e Instalación de luminaria tipo panel stil led backlight 60X60cm 40W, 3000K-6500K, 4051lm, IP40 montaje de sobreponer o incrustar, chasis de aluminio, acabado en pintura electrostática y difusor en policarbonato; VER FICHA TECNICA |  | 3d | 2026-04-21 | 2026-04-23 | 44SS |  |  | 2026-04-21 | 2026-04-23 | 3d | 5d |  |  | 18,999,200 | 18,999,200 |  |
| 42 | 1.5.1.19 | Suministro e Instalación de luminaria tipo panel stil led backlight 30X120cm 40W, 3000K-6500K, 3848lm, IP40 montaje de sobreponer o incrustar, chasis de aluminio, acabado en pintura electrostática y difusor en policarbonato; VER FICHA TECNICA |  | 3d | 2026-04-21 | 2026-04-23 | 44SS |  |  | 2026-04-21 | 2026-04-23 | 3d | 5d |  |  | 3,505,200 | 3,505,200 |  |
| 43 | 1.5.1.20 | Suministro e Instalación de luminaria tipo bala stil led Flat 22W, 100,000 horas, 4000K-6500K, 2261lm, IP65 incluye cilindro para aplicación de sobreponer de 15cm color blanco, chasis de aluminio, acabado en pintura electrostática y difusor en policarbona |  | 3d | 2026-04-21 | 2026-04-23 | 44SS |  |  | 2026-04-21 | 2026-04-23 | 3d | 5d |  |  | 1,409,700 | 1,409,700 |  |
| 44 | 1.5.1.21 | Suministro e Instalación de luminaria tipo panel led redondo 36W hermética IP65 acabado en pintura electrostática y difusor en policarbonato; VER FICHA TECNICA |  | 3d | 2026-04-21 | 2026-04-23 | 49SS+2d |  |  | 2026-04-21 | 2026-04-23 | 3d | 5d | 0d |  | 2,844,800 | 2,844,800 |  |
| 45 | 1.5.1.22 | Suministro e Instalación de luminaria tipo panel led redondo 27W hermética acabado en pintura electrostática y difusor en policarbonato, Batería de emergencia integrada de 20W, autonomía de 2 horas; VER FICHA TECNICA |  | 3d | 2026-04-17 | 2026-04-21 | 49SS |  |  | 2026-04-17 | 2026-04-21 | 3d | 7d |  |  | 1,600,200 | 1,600,200 |  |
| 46 | 1.5.1.23 | Desmonte,limpieza, desinfeccion mantenimiento y reinstalacion de luminaria de incrustar o sobreponer existente de 30x120cm o 60x60 cm, panel circular led VER FICHA TECNICA |  | 4d | 2026-04-01 A | 2026-04-06 A | 24SS | 100% |  | 2026-04-01 | 2026-04-06 | 4d |  |  |  | 798,830 | 798,830 | 798,830 |
| 47 | 1.5.1.24 | Suministro e instalación de aplique de emergencia Stil LED bala de 5W, para incrustar, carcasa o cuerpo termoplástico ABS VER FICHA TECNICA |  | 4d | 2026-04-21 | 2026-04-24 | 48 |  |  | 2026-04-21 | 2026-04-24 | 4d | 1d | 0d |  | 18,821,400 | 18,821,400 |  |
| 48 | 1.5.1.25 | Suministro e instalación de aplique de emergencia Stil LED IP65 3W, para incrustar, VER FICHA TECNICA |  | 2d | 2026-04-17 | 2026-04-20 | 49SS |  |  | 2026-04-17 | 2026-04-20 | 2d | 1d | 0d |  | 819,150 | 819,150 |  |
| 49 | 1.5.1.26 | Suministro e instalación de aplique de emergencia Stil LED aviso de salida 1W letras verdes, VER FICHA TECNICA |  | 2d | 2026-04-17 | 2026-04-20 | 37 |  |  | 2026-04-17 | 2026-04-20 | 2d | 0d |  |  | 3,810,000 | 3,810,000 |  |
| 50 | 1.5.1.27 | Suministro de materiales y mano de obra para Instalación de tuberia conduit EMT de 1" para circuitos VER FICHA TECNICA |  | 6d | 2026-04-17 | 2026-04-24 | 49SS |  |  | 2026-04-17 | 2026-04-24 | 6d | 0d |  |  | 3,956,050 | 3,956,050 |  |
| 51 | 1.5.1.28 | Suministro de materiales y mano de obra para Instalación de tuberia conduit EMT de 3/4" para circuitos VER FICHA TECNICA |  | 8d | 2026-03-30 A | 2026-04-08 A | 18SS | 100% |  | 2026-03-30 | 2026-04-08 | 8d |  |  |  | 24,352,250 | 24,352,250 | 24,352,250 |
| 52 | 1.5.1.29 | Suministro de materiales y mano de obra para Instalación de tuberia conduit IMC de 1" para circuitos VER FICHA TECNICA |  | 7d | 2026-04-17 | 2026-04-27 | 50SS |  |  | 2026-04-17 | 2026-04-27 | 7d | 0d |  |  | 812,800 | 812,800 |  |
| 53 | 1.5.1.30 | Suministro de materiales y mano de obra para Instalación de tuberia conduit IMC de 3/4" para circuitos VER FICHA TECNICA |  | 7d | 2026-04-01 A | 2026-04-09 A | 51SS+2d | 100% |  | 2026-04-01 | 2026-04-09 | 7d |  |  |  | 2,720,340 | 2,720,340 | 2,720,340 |
| 54 | 1.5.1.31 | Suministro de materiales y mano de obra para Instalación de conduleta LR o LL en aluminio inyectado para tuberia de 1", VER FICHA TECNICA |  | 7d | 2026-04-20 | 2026-04-28 | 50SS+1d |  |  | 2026-04-20 | 2026-04-28 | 7d | 2d |  |  | 609,600 | 609,600 |  |
| 55 | 1.5.1.32 | Suministro de materiales y mano de obra para Instalación de conduleta LR o LL en aluminio inyectado para tuberia de 3/4", VER FICHA TECNICA |  | 6d | 2026-04-01 A | 2026-04-08 A | 53SS | 100% |  | 2026-04-01 | 2026-04-08 | 6d |  |  |  | 731,520 | 731,520 | 731,520 |
| 56 | 1.5.1.33 | Suministro de materiales y mano de obra para Instalación de tuberia flexible tipo americana conduit liquid tight de 3/4" alimentadores circuitos de distribución;VER FICHA TECNICA |  | 8d | 2026-04-01 A | 2026-04-10 A | 53SS | 100% |  | 2026-04-01 | 2026-04-10 | 8d |  |  |  | 2,560,320 | 2,560,320 | 2,560,320 |
| 57 | 1.5.1.34 | Suministro e instalación de conductores, cable de cobre trenzado calibre 3x12 AWG LSZH fase roja, VER FICHA TECNICA |  | 5d | 2026-04-13 A | 2026-04-17 | 56 | 40% | 3d | 2026-04-13 | 2026-04-17 | 5d | 9d |  |  | 10,109,200 | 10,109,200 | 4,043,680 |
| 58 | 1.5.1.35 | Suministro de materiales y mano de obra para Instalación de canaleta de superficie plástica dexson o similar 100x45 con división y tapa; VER FICHA TECNICA |  | 5d | 2026-04-02 A | 2026-04-08 A | 53SS+1d | 100% |  | 2026-04-02 | 2026-04-08 | 5d |  |  |  | 4,953,000 | 4,953,000 | 4,953,000 |
| 59 | 1.5.1.36 | Suministro de materiales y mano de obra para Instalación de accesorios salida cable bandeja Cablofild; VER FICHA TECNICA |  | 4d | 2026-04-02 A | 2026-04-07 A | 58SS | 100% |  | 2026-04-02 | 2026-04-07 | 4d |  |  |  | 304,800 | 304,800 | 304,800 |
| 60 | 1.5.1.37 | Suministro de materiales y mano de obra para montaje e instalación de bandeja portacables electrozincada de 30 x 5,4 cm (Ancho x Alto) tipo malla electrosoldada en acero ASTM 1006-1008 con división, VER FICHA TECNICA |  | 4d | 2026-04-02 A | 2026-04-07 A | 58SS | 100% |  | 2026-04-02 | 2026-04-07 | 4d |  |  |  | 15,049,500 | 15,049,500 | 15,049,500 |
| 61 | 1.5.1.38 | Suministro de materiales y mano de obra para montaje e instalación de tapa para bandeja portacables electrozincada de 30 x 5,4 cm (Ancho x Alto); VER FICHA TECNICA |  | 3d | 2026-04-07 A | 2026-04-09 A | 62 | 100% |  | 2026-04-07 | 2026-04-09 | 3d |  |  |  | 3,329,940 | 3,329,940 | 3,329,940 |
| 62 | 1.5.1.39 | Suministro e instalación de conductores, acometida en cable de cobre calibre 3x12F+12N+12T AWG THHN/THHW de interconexión entre tableros VER FICHA TECNICA |  | 3d | 2026-04-02 A | 2026-04-06 A | 58SS | 100% |  | 2026-04-02 | 2026-04-06 | 3d |  |  |  | 2,743,200 | 2,743,200 | 2,743,200 |

| ID | WBS | Task | Duration | Start | Finish | Predecessors | Baseline start | Baseline finish | Baseline duration | Total slack | Free slack | Cost | Baseline cost |
| --- | --- | --- | --- | --- | --- | --- | --- | --- | --- | --- | --- | --- | --- |
| 63 | 1.5.2 | **SISTEMA DE ALARMAS Y DETECCION DE INCENDIOS** | 8d | 2026-04-17 | 2026-04-28 |  | 2026-04-17 | 2026-04-28 | 8d | 0d |  | 31,982,410 | 31,982,410 |
| 64 | 1.5.2.1 | Desmonte, retiro y reintalación de salida para sensor de humo fotoeléctrico , termico y elementos activos del sistema, estación manual y estrobo multicandela; VER FICHA TECNICA | 4d | 2026-04-17 | 2026-04-22 | 52SS | 2026-04-17 | 2026-04-22 | 4d | 0d |  | 4,533,900 | 4,533,900 |
| 65 | 1.5.2.2 | Desmonte , retiro, mantenimiento y reinstalacion de sensor de humo electrico y elementos activos del sistema, estacion manual y estrobo multicandela VER FICHA TECNICA | 4d | 2026-04-17 | 2026-04-22 | 64SS | 2026-04-17 | 2026-04-22 | 4d | 6d |  | 701,040 | 701,040 |
| 66 | 1.5.2.3 | Desmonte retiro, mantenimiento y reinstalacion de estacion manual VER FICHA TECNICA | 4d | 2026-04-17 | 2026-04-22 | 64SS | 2026-04-17 | 2026-04-22 | 4d | 0d |  | 317,500 | 317,500 |
| 67 | 1.5.2.4 | Desmonte, retiro , mantenimiento y reinstalacion de estrobo multicandela con sirena electronica, montado en pared;VER FICHA TECNICA | 4d | 2026-04-17 | 2026-04-22 | 64SS | 2026-04-17 | 2026-04-22 | 4d | 6d |  | 548,640 | 548,640 |
| 68 | 1.5.2.5 | Desmonte y retiro de sensor de humo fotoeléctrico, termico o de doble tecnologia ;VER FICHA TECNICA | 4d | 2026-04-17 | 2026-04-22 | 64SS | 2026-04-17 | 2026-04-22 | 4d | 6d |  | 365,760 | 365,760 |
| 69 | 1.5.2.6 | Suministro de materiales y mano de obra para Instalación de salida para sensores,estaciones manuales y estrobos multicandela y elementos activos del sistema en caja fundida en aluminio inyectado VER FICHA TECNICA | 4d | 2026-04-23 | 2026-04-28 | 74 | 2026-04-23 | 2026-04-28 | 4d | 2d |  | 5,783,580 | 5,783,580 |
| 70 | 1.5.2.7 | Suministro e Instalación de Sensor de humo fotoeléctrico direccionable listado UL; VER FICHA TECNICA | 4d | 2026-04-23 | 2026-04-28 | 74 | 2026-04-23 | 2026-04-28 | 4d | 1d | 0d | 11,734,800 | 11,734,800 |
| 71 | 1.5.2.8 | Suministro e Instalación de Sensor doble tecnologia humo,fotoelectrico y temperatura direccionable listado UL; VER FICHA TECNICA | 3d | 2026-04-23 | 2026-04-27 | 70SS | 2026-04-23 | 2026-04-27 | 3d | 2d | 0d | 1,498,600 | 1,498,600 |
| 72 | 1.5.2.9 | Suministro e Instalación de Strobo multicandela con sirena electrónica 12V/24V, intensidad seleccionable, sincronizado a 1hz con el Flash, montura en pared, color rojo, listado UL VER FICHA TECNICA | 4d | 2026-04-23 | 2026-04-28 | 71SS | 2026-04-23 | 2026-04-28 | 4d | 2d |  | 546,100 | 546,100 |
| 73 | 1.5.2.10 | Suministro e Instalación de Estación Manual direccionable, 24 V CC, Color rojo, doble acción, función de reincio de bloqueo de teclas contactos de alarma en oro-plata para aumentar resistencia a la corrosión y superficie a prueba de agua; VER FICHA TECNIC | 3d | 2026-04-23 | 2026-04-27 | 70SS | 2026-04-23 | 2026-04-27 | 3d | 3d |  | 1,524,000 | 1,524,000 |
| 74 | 1.5.2.11 | Suministro de materiales y mano de obra para instalación de alambre alarma de cobre FPLR 2x16 AWG norma UL; VER FICHA TECNICA | 4d | 2026-04-17 | 2026-04-22 | 66SS | 2026-04-17 | 2026-04-22 | 4d | 0d |  | 3,285,490 | 3,285,490 |
| 75 | 1.5.2.12 | Mantenimiento a panel de alarmas principal y sus componente .VER FICHA TECNICA | 3d | 2026-04-23 | 2026-04-27 | 70SS | 2026-04-23 | 2026-04-27 | 3d | 3d |  | 1,143,000 | 1,143,000 |
| 76 | 1.5.3 | **SISTEMAS DE INYECCION** | 5d | 2026-04-23 | 2026-04-29 |  | 2026-04-23 | 2026-04-29 | 5d | 1d |  | 52,542,440 | 52,542,440 |
| 77 | 1.5.3.1 | Suministro de materiales y mano de obra para realizar el mantenimiento de unidad manejadora sistema de inyeccion 3500 cfm existente, VER FICHA TECNICA | 3d | 2026-04-23 | 2026-04-27 | 70SS | 2026-04-23 | 2026-04-27 | 3d | 1d | 0d | 2,286,000 | 2,286,000 |
| 78 | 1.5.3.2 | Desmonte, retiro y disposición final de ductos del sistema de extracción, inyeccion o de recirculacion existente,VER FICHA TECNICA | 3d | 2026-04-23 | 2026-04-27 | 70SS | 2026-04-23 | 2026-04-27 | 3d | 1d | 0d | 284,480 | 284,480 |
| 79 | 1.5.3.3 | Suministro e instalación de bandas de lona entrada y salida del ventilador de aproximadamente 50cm de ancho, acoplada a los ductos y figuras de descarga y succión;VER FICHA TECNICA | 3d | 2026-04-24 | 2026-04-28 | 77SS+1d | 2026-04-24 | 2026-04-28 | 3d | 2d |  | 1,752,600 | 1,752,600 |
| 80 | 1.5.3.4 | Ducto ó figura TDC CALIBRE 24 Fabricado a todo costoVER FICHA TECNICA | 5d | 2026-04-23 | 2026-04-29 | 78SS | 2026-04-23 | 2026-04-29 | 5d | 1d |  | 4,785,360 | 4,785,360 |
| 81 | 1.5.3.5 | Ducto ó figura TDC CALIBRE 24 Fabricado a todo costo debidamente reforzados e instalados con sus respectiva soportería y acoplados a la reducción de la misma dimension, tanto en descarga como en succión, debidamente aislado térmicamente para evitar la con | 4d | 2026-04-23 | 2026-04-28 | 78SS | 2026-04-23 | 2026-04-28 | 4d | 2d |  | 1,409,700 | 1,409,700 |
| 82 | 1.5.3.6 | Ducto ó figura TDC CALIBRE 24 Fabricado a todo costo, debidamente reforzados e instalados con sus respectiva soportería y acoplados a la reducción de la misma dimension), tanto en succion como en descarga.debidamente aislado termicamente para evitar la co | 4d | 2026-04-23 | 2026-04-28 | 78SS | 2026-04-23 | 2026-04-28 | 4d | 2d |  | 1,866,900 | 1,866,900 |
| 83 | 1.5.3.7 | Ducto ó figura TDC CALIBRE 22 Fabricado a todo costo VER FICHA TECNICA | 4d | 2026-04-23 | 2026-04-28 | 78SS | 2026-04-23 | 2026-04-28 | 4d | 2d |  | 2,204,720 | 2,204,720 |
| 84 | 1.5.3.8 | Ducto ó figura TDC CALIBRE 22 Fabricado a todo costo debidamente reforzados e instalados con sus respectiva soportería y acoplados a la reducción de la misma dimension, tanto en descarga como en succión, debidamente aislado térmicamente para evitar la con | 4d | 2026-04-23 | 2026-04-28 | 78SS | 2026-04-23 | 2026-04-28 | 4d | 2d |  | 4,104,640 | 4,104,640 |
| 85 | 1.5.3.9 | Suministro e instalación de pre filtros plata o similar para retención de partículas 24"X24"X2" VER FICHA TECNICA | 3d | 2026-04-23 | 2026-04-27 | 77SS | 2026-04-23 | 2026-04-27 | 3d | 1d | 0d | 1,524,000 | 1,524,000 |
| 86 | 1.5.3.10 | Suministro e instalación de fltros de carbón activado tipo granular o peletizado para retención de olores y vapores 24"X24"X2" , VER FICHA TECNICA | 3d | 2026-04-23 | 2026-04-27 | 85SS | 2026-04-23 | 2026-04-27 | 3d | 3d |  | 1,752,600 | 1,752,600 |
| 87 | 1.5.3.11 | Suministro e instalación de filtros de permanganato de potasio o alumina u otro tipo de elemento germicida tipo granular o peletizado 24"X24"X11" VER FICHA TECNICA | 3d | 2026-04-23 | 2026-04-27 | 85SS | 2026-04-23 | 2026-04-27 | 3d | 3d |  | 14,478,000 | 14,478,000 |
| 88 | 1.5.3.12 | Suministro e instalación de filtros HEPA para retención de partículas de 0,3 micras con una eficiencia mínima del 99.97% con estructura en aluminio 24"X24"X11" con marco en aluminio; VER FICHA TECNICA | 3d | 2026-04-23 | 2026-04-27 | 85SS | 2026-04-23 | 2026-04-27 | 3d | 1d | 0d | 7,239,000 | 7,239,000 |
| 89 | 1.5.3.13 | Mantenimiento de tablero de fuerza y control, control de encendido remoto sitemas de aire acondicionado y extracción , VER FICHA TECNICA | 3d | 2026-04-27 | 2026-04-29 | 88SS+2d | 2026-04-27 | 2026-04-29 | 3d | 1d |  | 952,500 | 952,500 |
| 90 | 1.5.3.14 | Rejilla difusora 4 vias de aire 10X10 pulgadas, dotada de damper para ajuste de caudal (ver Rejillas comerciales)VER FICHA TECNICA | 3d | 2026-04-23 | 2026-04-27 | 88SS | 2026-04-23 | 2026-04-27 | 3d | 3d |  | 7,901,940 | 7,901,940 |

| ID | WBS | Task | Duration | Start | Finish | Predecessors | Complete | Remaining | Baseline start | Baseline finish | Baseline duration | Total slack | Free slack | Cost | Baseline cost | Actual cost |
| --- | --- | --- | --- | --- | --- | --- | --- | --- | --- | --- | --- | --- | --- | --- | --- | --- |
| 91 | 1.6 | **VOZ Y DATOS** | 5d | 2026-04-23 | 2026-04-29 |  |  |  | 2026-04-23 | 2026-04-29 | 5d | 1d |  | 118,826,280 | 118,826,280 |  |
| 92 | 1.6.1 | Suministro, instalación de Cable UTP Cat. 6A 4 pares 24 AWG (datos) U/UTP VER FICHA TECNICA | 3d | 2026-04-23 | 2026-04-27 | 70SS |  |  | 2026-04-23 | 2026-04-27 | 3d | 1d | 0d | 107,259,120 | 107,259,120 |  |
| 93 | 1.6.2 | Suministro, instalación y conectorización de Tomas sencillas cat. 6A RJ 45 (datos) y Voz VER FICHA TECNICA | 3d | 2026-04-23 | 2026-04-27 | 92SS |  |  | 2026-04-23 | 2026-04-27 | 3d | 3d |  | 4,439,920 | 4,439,920 |  |
| 94 | 1.6.3 | Suministro, instalación y conectorización de Face Plate para modulo doble cat. 6A RJ 45 VER FICHA TECNICA | 3d | 2026-04-27 | 2026-04-29 | 92SS+2d |  |  | 2026-04-27 | 2026-04-29 | 3d | 1d | 0d | 1,402,080 | 1,402,080 |  |
| 95 | 1.6.4 | Suministro e Instalación de Pacth cord de 9 pies cat. 6A U/UTP de datos y Voz VER FICHA TECNICA | 2d | 2026-04-27 | 2026-04-28 | 94SS |  |  | 2026-04-27 | 2026-04-28 | 2d | 1d | 0d | 2,219,960 | 2,219,960 |  |
| 96 | 1.6.5 | Certificacion de puntos de datos y voz con soporte impreso y en medio magnético. VER FICHA TECNICA | 1d | 2026-04-29 | 2026-04-29 | 95 |  |  | 2026-04-29 | 2026-04-29 | 1d | 1d |  | 3,505,200 | 3,505,200 |  |
| 97 | 1.7 | **MUROS, PAÑETES Y ENCHAPES** | 11d | 2026-04-07 A | 2026-04-21 |  | 62% | 4.23d | 2026-04-07 | 2026-04-21 | 11d | 7d |  | 69,649,975 | 69,649,975 | 38,890,575 |
| 98 | 1.7.1 | Pañete liso impermeabilizado 1:3, incluye filos, dilataciones, cantos y carteras de baños. incluye medidas inferiores a 1.00 m VER FICHA TECNICA | 2d | 2026-04-09 A | 2026-04-10 A | 99 | 100% |  | 2026-04-09 | 2026-04-10 | 2d |  |  | 577,850 | 577,850 | 577,850 |
| 99 | 1.7.2 | Construccion de muro en bloque N° 5 VER FICHA TECNICA | 2d | 2026-04-07 A | 2026-04-08 A | 24 | 100% |  | 2026-04-07 | 2026-04-08 | 2d |  |  | 395,605 | 395,605 | 395,605 |
| 100 | 1.7.3 | Construccion de muro en lamina de Superboard de 6 mm doble cara, 10 cm de espesor, VER FICHA TECNICA | 5d | 2026-04-09 A | 2026-04-15 | 99 | 80% | 1d | 2026-04-09 | 2026-04-15 | 5d | 3d | 0d | 47,396,400 | 47,396,400 | 37,917,120 |
| 101 | 1.7.4 | suministro e instalacion mediacaña vertical en pvc 6 cm para union muro-muro, VER FICHA TECNICA | 2d | 2026-04-16 | 2026-04-17 | 100 |  |  | 2026-04-16 | 2026-04-17 | 2d | 7d | 0d | 7,061,200 | 7,061,200 |  |
| 102 | 1.7.5 | Suministro e instalación frescasa de 9cm entre muros de fibrocemento, VER FICHA TECNICA | 2d | 2026-04-20 | 2026-04-21 | 101 |  |  | 2026-04-20 | 2026-04-21 | 2d | 7d |  | 14,218,920 | 14,218,920 |  |
| 103 | 1.8 | **BASES Y PISOS** | 8d | 2026-04-16 | 2026-04-27 |  |  |  | 2026-04-16 | 2026-04-27 | 8d | 3d |  | 9,277,350 | 9,277,350 |  |
| 104 | 1.8.1 | Suministro e instalacion de guarda escoba media caña en PVC 8 cm, en rollo color a escoger, VER FICHA TECNICA | 5d | 2026-04-16 | 2026-04-22 | 100 |  |  | 2026-04-16 | 2026-04-22 | 5d | 3d | 0d | 8,515,350 | 8,515,350 |  |
| 105 | 1.8.2 | Suministro e instalación de Piso en granito pulido,VER FICHA TECNICA | 8d | 2026-04-16 | 2026-04-27 | 104SS |  |  | 2026-04-16 | 2026-04-27 | 8d | 3d |  | 762,000 | 762,000 |  |
| 106 | 1.9 | **CIELORRASOS** | 7d | 2026-04-17 | 2026-04-27 |  |  |  | 2026-04-17 | 2026-04-27 | 7d | 0d |  | 51,636,930 | 51,636,930 |  |
| 107 | 1.9.1 | Suministro e instalación de cielorraso en lámina de superboard 6mm. VER FICHA TECNICA | 5d | 2026-04-17 | 2026-04-23 | 74SS |  |  | 2026-04-17 | 2026-04-23 | 5d | 0d |  | 26,803,350 | 26,803,350 |  |
| 108 | 1.9.2 | Suministro e instalación de escotillas de cielorraso 60 x 60 cm VER FICHA TECNICA | 2d | 2026-04-24 | 2026-04-27 | 107 |  |  | 2026-04-24 | 2026-04-27 | 2d | 3d |  | 12,344,400 | 12,344,400 |  |
| 109 | 1.9.3 | suministro e instalacion mediacaña horizontal en pvc 6 cm para union muro-cielofalso, VER FICHA TECNICA | 2d | 2026-04-22 | 2026-04-23 | 112SS |  |  | 2026-04-22 | 2026-04-23 | 2d | 5d |  | 12,489,180 | 12,489,180 |  |
| 110 | 1.10 | **PINTURAS** | 6d | 2026-04-17 | 2026-04-24 |  |  |  | 2026-04-17 | 2026-04-24 | 6d | 0d |  | 65,135,506 | 65,135,506 |  |
| 111 | 1.10.1 | Suministro y aplicacion de estuco acrílico, VER FICHA TECNICA | 3d | 2026-04-17 | 2026-04-21 | 107SS |  |  | 2026-04-17 | 2026-04-21 | 3d | 0d |  | 4,104,640 | 4,104,640 |  |
| 112 | 1.10.2 | Suministro e instalación de pintura epóxica poliamida, recubrimiento protector para muros y techos interiores VER FICHA TECNICA | 3d | 2026-04-22 | 2026-04-24 | 111 |  |  | 2026-04-22 | 2026-04-24 | 3d | 0d |  | 61,030,866 | 61,030,866 |  |
| 113 | 1.11 | **CARPINTERIA ALUMINIO Y VIDRIOS** | 2d | 2026-04-27 | 2026-04-28 |  |  |  | 2026-04-27 | 2026-04-28 | 2d | 0d |  | 64,998,600 | 64,998,600 |  |
| 114 | 1.11.1 | Suministro e instalación ventana en aluminio fija o corrediza o batiente o proyectante VER FICHA TECNICA | 2d | 2026-04-27 | 2026-04-28 | 112 |  |  | 2026-04-27 | 2026-04-28 | 2d | 0d |  | 8,001,000 | 8,001,000 |  |
| 115 | 1.11.2 | Puerta batiente de una hoja, marco en aluminio REF 1102 VER FICHA TECNICA | 2d | 2026-04-27 | 2026-04-28 | 114SS |  |  | 2026-04-27 | 2026-04-28 | 2d | 0d |  | 56,997,600 | 56,997,600 |  |

| ID | WBS | Task | Type | Duration | Start | Finish | Predecessors | Baseline start | Baseline finish | Baseline duration | Total slack | Free slack | Cost | Baseline cost |
| --- | --- | --- | --- | --- | --- | --- | --- | --- | --- | --- | --- | --- | --- | --- |
| 116 | 1.12 | **MOBILIARIO** |  | 3d | 2026-04-27 | 2026-04-29 |  | 2026-04-27 | 2026-04-29 | 3d | 1d |  | 355,282,500 | 355,282,500 |
| 117 | 1.12.1 | Suministro e instalación mueble lavamanos elevado tipo aluvia, en madera aglomerada VER FICHA TECNICA |  | 1d | 2026-04-27 | 2026-04-27 | 115SS | 2026-04-27 | 2026-04-27 | 1d | 3d |  | 7,569,200 | 7,569,200 |
| 118 | 1.12.2 | Suministro e instalacion lavamanos tipo aquajet institucional, VER FICHA TECNICA |  | 1d | 2026-04-29 | 2026-04-29 | 121SS | 2026-04-29 | 2026-04-29 | 1d | 1d | 0d | 863,600 | 863,600 |
| 119 | 1.12.3 | Suministro e instalcion griferia para lavamanos tipo push institucional,VER FICHA TECNICA |  | 1d | 2026-04-29 | 2026-04-29 | 118SS | 2026-04-29 | 2026-04-29 | 1d | 1d |  | 635,000 | 635,000 |
| 120 | 1.12.4 | Suministro e instalacion barra de seguridad sanitaria tipo H, VER FICHA TECNICA |  | 1d | 2026-04-29 | 2026-04-29 | 121SS | 2026-04-29 | 2026-04-29 | 1d | 1d |  | 838,200 | 838,200 |
| 121 | 1.12.5 | Suministro e instalación sanitario tipo institucional, Cs Handicap 4,8 Lpf , VER FICHA TECNICA |  | 1d | 2026-04-29 | 2026-04-29 | 115 | 2026-04-29 | 2026-04-29 | 1d | 1d | 0d | 952,500 | 952,500 |
| 122 | 1.12.6 | SILLA Q1 ALTA OPERATIVA (ESCRITORIOS - MESA DE REUINONES),Giratoria malla / Espaldar alto /Asiento ejecutivo con espuma inyectada y tela tipo 2VER FICHA TECNICA. |  | 1d | 2026-04-29 | 2026-04-29 | 124SS | 2026-04-29 | 2026-04-29 | 1d | 0d |  | 27,432,000 | 27,432,000 |
| 123 | 1.12.7 | Superficie en L elaborada en tablex de 25 mm, enchapada en cara superior en formica F8 acabado madera VER FICHA TECNICA |  | 1d | 2026-04-29 | 2026-04-29 | 115 | 2026-04-29 | 2026-04-29 | 1d | 0d |  | 234,696,000 | 234,696,000 |
| 124 | 1.12.8 | ARCHIVOS 2X1 Estructura elaborada en fibra de madera natural, enchapada en formica F8 VER FICHA TECNICA |  | 1d | 2026-04-29 | 2026-04-29 | 123SS | 2026-04-29 | 2026-04-29 | 1d | 0d |  | 82,296,000 | 82,296,000 |
| 125 | 1.13 | ACTIVIDADES ADICIONALES |  | 1d | 2026-04-30 | 2026-04-30 | 122 | 2026-04-30 | 2026-04-30 | 1d | 0d |  | 194,271,752.97 | 194,271,752.97 |
| 126 | 1.14 | FIN | milestone | 0d | 2026-04-30 | 2026-04-30 | 125 | 2026-04-30 | 2026-04-30 | 0d | 0d |  |  |  |
